# Сопроводительный файл

Schedule from MS Project, 2002-01-10 to 2002-04-17, costs in $, A marks actual dates.
MS Project 2002
Отображаем перегруженные ресурсы на диаграмме использования ресурсов.

## Calendars

- Standard: Mon-Fri 08:00-12:00, 13:00-17:00; Sat-Sun off.

## Resources

| Resource | Group | Rate | Cost per use |
| --- | --- | --- | --- |
| Иванов | Редактор раздела | 6.25 |  |
| Петров | Редактор раздела | 6.25 |  |
| Сидоров | Редактор раздела | 7.5 |  |
| Галкина | Отвественный секретарь | 3.12 |  |
| Уваров | Главный редактор | 12.5 |  |
| Васин | Технический редактор | 5 |  |
| Козлов | Технический редактор | 5 |  |
| Баранов | Корректор | 3.12 |  |
| Ураганов | Корректор | 3.12 |  |
| Еремин | Дизайнер | 7.5 |  |
| Жуков | Фотограф | 3.12 |  |
| Сергеева | Верстальщик | 3.75 |  |
| Улендеева | Верстальщик | 4.69 |  |
| Лимонов | Оператор Mac | 5 |  |
| Бурков | Оператор Mac | 3.12 |  |
| Семенов | Оператор Mac | 4.69 |  |
| Борисов | Оператор печатного аппарата | 3.12 |  |
| Тарарухин | Оператор печатного аппарата | 3.44 |  |
| Терехов | Оператор печатного аппарата | 2.5 |  |
| Фотомодель по контракту | Фотомодель | 50 | 100 |

## Schedule

| ID | WBS | Task | Type | Duration | Start | Finish | Predecessors | Complete | Remaining | Baseline start | Baseline finish | Baseline duration | Total slack | Free slack | Constraint | Resources | Work | Actual work | Cost | Baseline cost | Actual cost | Text1 |
| --- | --- | --- | --- | --- | --- | --- | --- | --- | --- | --- | --- | --- | --- | --- | --- | --- | --- | --- | --- | --- | --- | --- |
| 1 | PUBL | **Подготовка номера журнала к изданию** |  | 69.83d | 2002-01-10 A | 2002-04-17 |  | 23% | 53.8d | 2002-01-10 | 2002-04-01 | 58d | 0d |  |  |  | 1542.13h | 222.33h | 11,520.7 | 9,443.98 | 2,158.28 |  |
| 2 | PUBLAAA | **Планирование номера** |  | 13d | 2002-01-10 A | 2002-01-28 A |  | 100% |  | 2002-01-10 | 2002-01-25 | 12d |  |  |  |  | 105.93h | 105.93h | 728.28 | 620.04 | 728.28 |  |
| 3 | PUBLAAA-1 | Сбор предложений от авторов |  | 6d | 2002-01-10 A | 2002-01-17 A |  | 100% |  | 2002-01-10 | 2002-01-16 | 5d |  |  | start no earlier than 2002-01-07 | Иванов [16.7%]; Петров [25%]; Сидоров [20%] | 26h | 26h | 192.5 | 180 | 192.5 |  |
| 4 | PUBLAAA-2 | Подготовка плана номера |  | 3d | 2002-01-17 A | 2002-01-21 A | 3 | 100% |  | 2002-01-17 | 2002-01-21 | 3d |  |  |  | Иванов [20%]; Петров [20.8%]; Сидоров [20%]; Галкина [12.5%] | 17.6h | 17.6h | 106.62 | 126 | 106.62 |  |
| 5 | PUBLAAA-3 | Предварительная редколлегия |  | 1d | 2002-01-22 A | 2002-01-22 A | 4 | 100% |  | 2002-01-22 | 2002-01-22 | 1d |  |  |  | Иванов [50%]; Петров [27.1%]; Сидоров [27.1%]; Уваров [50%]; Галкина [62.5%] | 17.33h | 17.33h | 120.41 | 109.02 | 120.41 |  |
| 6 | PUBLAAA-4 | Доработка планов с учетом замечаний |  | 3d | 2002-01-23 A | 2002-01-25 A | 5 | 100% |  | 2002-01-23 | 2002-01-24 | 2d |  |  |  | Иванов [43.8%]; Петров [31.2%]; Сидоров [37.5%] | 27h | 27h | 180 | 96 | 180 |  |
| 7 | PUBLAAA-5 | Редколлегия |  | 1d | 2002-01-28 A | 2002-01-28 A | 6 | 100% |  | 2002-01-25 | 2002-01-25 | 1d |  |  |  | Иванов [50%]; Петров [37.5%]; Сидоров [37.5%]; Уваров [50%]; Галкина [50%] | 18h | 18h | 128.75 | 109.02 | 128.75 |  |
| 8 | PUBLAAA-6 | План номера утвержден | milestone | 0d | 2002-01-28 A | 2002-01-28 A | 7 | 100% |  | 2002-01-25 | 2002-01-25 | 0d |  |  |  |  |  |  |  |  |  |  |
| 9 | PUBLAAB | **Подготовка текстов** |  | 34.33d | 2002-01-29 A | 2002-03-18 |  | 23% | 26.59d | 2002-01-28 | 2002-03-13 | 33d | 19.5d |  |  |  | 627.2h | 92.4h | 5,109.5 | 4,358.5 | 802.5 |  |
| 10 | PUBLAAB-1 | Подготовка редакционных заданий |  | 3d | 2002-01-29 A | 2002-01-31 A | 8 | 100% |  | 2002-01-28 | 2002-01-30 | 3d |  |  |  | Иванов [50%]; Петров [58.3%]; Сидоров [50%]; Уваров [33.3%] | 46h | 46h | 352.5 | 262.5 | 352.5 |  |
| 11 | PUBLAAB-2 | Рассылка заданий авторам |  | 2d | 2002-02-01 A | 2002-02-04 A | 10 | 100% |  | 2002-01-31 | 2002-01-31 | 1d |  |  |  | Уваров [150%] | 24h | 24h | 300 | 25 | 300 |  |
| 12 | PUBLAAB-3 | Утверждение заданий |  | 3.33d | 2002-02-05 A | 2002-02-08 A | 11 | 100% |  | 2002-02-01 | 2002-02-05 | 3d |  |  |  | Иванов [30%]; Петров [30%]; Сидоров [30%]; Васин [30%] | 22.4h | 22.4h | 150 | 144 | 150 |  |
| 13 | PUBLAAB-4 | Статьи в работе у авторов | milestone | 0d | 2002-02-08 A | 2002-02-08 A | 12 | 100% |  | 2002-02-05 | 2002-02-05 | 0d |  |  |  |  |  |  |  |  |  |  |
| 14 | PUBLAAB-5 | Статьи поступили в редакцию | milestone | 0d | 2002-02-22 | 2002-02-22 | 13FS+10d |  |  | 2002-02-19 | 2002-02-19 | 0d | 0d |  |  |  |  |  | 1,000 | 1,000 |  |  |
| 15 | PUBLAAB-6 | Редактирование материалов |  | 14.62d | 2002-02-22 | 2002-03-14 | 14 |  |  | 2002-02-20 | 2002-03-05 | 10d | 0d |  |  | Иванов [46.1%]; Петров [46.1%]; Сидоров [46.1%] | 154h |  | 1,025 | 960 |  |  |
| 16 | PUBLAAB-7 | Техническое редактирование |  | 14d | 2002-02-26 | 2002-03-18 | 15SS+2d |  |  | 2002-02-22 | 2002-03-13 | 14d | 0d |  |  | Козлов; Баранов; Уваров [50%]; Иванов [30%]; Петров [30%]; Сидоров [30%] | 380.8h |  | 2,282 | 1,967 |  |  |
| 17 | PUBLAAB-8 | Подготовка текстов завершена | milestone | 0d | 2002-03-18 | 2002-03-18 | 16 |  |  | 2002-03-13 | 2002-03-13 | 0d | 19.5d | 0d |  |  |  |  |  |  |  |  |
| 18 | PUBLAAC | **Верстка журнала** |  | 41.33d | 2002-01-29 A | 2002-03-27 |  | 16% | 34.81d | 2002-01-28 | 2002-03-22 | 40d | 15.5d |  |  |  | 579.2h | 24h | 3,391 | 3,613.5 | 627.5 |  |
| 19 | PUBLAAC-1 | **Подготовка обложки** |  | 37.33d | 2002-01-29 A | 2002-03-21 | 8 | 60% | 14.93d | 2002-01-28 | 2002-03-18 | 36d | 19.5d |  |  |  | 59.2h | 24h | 818 | 1,430.5 | 627.5 |  |
| 20 | PUBLAAC-1.1 | Кастинг для выбора фотомодели |  | 5d | 2002-01-29 A | 2002-02-04 A |  | 100% |  | 2002-01-28 | 2002-02-01 | 5d |  |  |  |  |  |  | 500 | 500 | 500 |  |
| 21 | PUBLAAC-1.2 | Фотосъемка модели |  | 4d | 2002-02-05 A | 2002-02-08 A | 20 | 100% |  | 2002-02-04 | 2002-02-06 | 3d |  |  |  | Ураганов [37.5%]; Еремин [37.5%] | 24h | 24h | 127.5 | 687.5 | 127.5 |  |
| 22 | PUBLAAC-1.3 | Подготовка макета обложки |  | 3d | 2002-02-11 | 2002-02-13 | 21 |  |  | 2002-02-07 | 2002-02-11 | 3d | 41.83d | 22.33d |  | Жуков [70%]; Еремин [20%] | 21.6h |  | 88.5 | 141 |  | WW |
| 23 | PUBLAAC-1.4 | Подготовка анонсов материалов номера для обложки |  | 3d | 2002-03-18 | 2002-03-21 | 17, 22 |  |  | 2002-03-14 | 2002-03-18 | 3d | 19.5d | 0d |  | Сидоров [70%] | 13.6h |  | 102 | 102 |  |  |
| 24 | PUBLAAC-1.5 | Обложка готова | milestone | 0d | 2002-03-21 | 2002-03-21 | 23 |  |  | 2002-03-18 | 2002-03-18 | 0d | 19.5d |  |  |  |  |  |  |  |  |  |
| 25 | PUBLAAC-2 | Обработка текста и иллюстраций |  | 14d | 2002-03-01 | 2002-03-21 | 16SS+3d |  |  | 2002-02-27 | 2002-03-18 | 14d | 0d |  |  | Сергеева; Улендеева | 224h |  | 945 | 945 |  |  |
| 26 | PUBLAAC-3 | Вычитка |  | 14d | 2002-03-06 | 2002-03-26 | 25SS+3d |  |  | 2002-03-04 | 2002-03-21 | 14d | 15.5d | 0d |  | Лимонов [50%]; Васин [50%] | 112h |  | 560 | 350 |  |  |
| 27 | PUBLAAC-4 | Сверка |  | 12d | 2002-03-11 | 2002-03-27 | 26SS+3d |  |  | 2002-03-07 | 2002-03-22 | 12d | 15.5d |  |  | Лимонов [50%]; Васин [50%]; Иванов [30%]; Петров [30%]; Сидоров [30%] | 182.4h |  | 1,056 | 876 |  |  |
| 28 | PUBLAAC-5 | Подготовка оглавления |  | 2d | 2002-03-21 | 2002-03-25 | 25 |  |  | 2002-03-19 | 2002-03-20 | 2d | 0d |  |  | Сидоров [10%] | 1.6h |  | 12 | 12 |  |  |
| 29 | PUBLAAC-6 | Номер сверстан | milestone | 0d | 2002-03-25 | 2002-03-25 | 28 |  |  | 2002-03-20 | 2002-03-20 | 0d | 0d |  |  |  |  |  |  |  |  |  |

| ID | WBS | Task | Type | Duration | Start | Finish | Predecessors | Baseline start | Baseline finish | Baseline duration | Total slack | Resources | Work | Cost | Baseline cost |
| --- | --- | --- | --- | --- | --- | --- | --- | --- | --- | --- | --- | --- | --- | --- | --- |
| 30 | PUBLAAD | **Предпечатная подготовка** |  | 17.5d | 2002-03-25 | 2002-04-17 |  | 2002-03-20 | 2002-04-01 | 8d | 0d |  | 229.8h | 2,291.92 | 851.93 |
| 31 | PUBLAAD-1 | Конвертция сверстанного номера в формат Mac |  | 7.5d | 2002-03-25 | 2002-04-03 | 29 | 2002-03-20 | 2002-03-25 | 3d | 0d | Бурков [25%]; Семенов [25%]; Борисов [25%] | 45h | 164.06 | 192.18 |
| 32 | PUBLAAD-2 | Цветоделение |  | 7d | 2002-04-03 | 2002-04-12 | 31 | 2002-03-25 | 2002-03-29 | 7d | 0d | Тарарухин [25%]; Терехов [25%]; Фотомодель по контракту [25%]; Семенов [20%]; Борисов [20%] | 64.4h | 895.62 | 214.37 |
| 33 | PUBLAAD-3 | Коррекция |  | 7d | 2002-04-04 | 2002-04-15 | 32SS+1d | 2002-03-26 | 2002-03-30 | 7d | 0d | Бурков [25%]; Семенов [25%]; Борисов [25%] | 42h | 153.12 | 179.37 |
| 34 | PUBLAAD-4 | Вывод пленок |  | 7d | 2002-04-08 | 2002-04-17 | 33SS+2d | 2002-03-28 | 2002-04-01 | 7d | 0d | Бурков [25%]; Семенов [25%]; Тарарухин [30%]; Терехов [30%]; Фотомодель по контракту [30%] | 78.4h | 1,079.12 | 266 |
| 35 | PUBLAAD-5 | Номер готов к передаче в типографию | milestone | 0d | 2002-04-17 | 2002-04-17 | 34 | 2002-04-01 | 2002-04-01 | 0d | 0d |  |  |  |  |
